# Dinamički plan hotela Mirjam Makarska

Schedule from MS Project, 2017-11-10 to 2018-06-30.

## Calendars

- Standard: Mon-Fri 08:00-12:00, 13:00-17:00; Sat-Sun off.

## Schedule

| ID | WBS | Task | Duration | Start | Finish | Total slack | Constraint |
| --- | --- | --- | --- | --- | --- | --- | --- |
| 1 | 1 | HOTEL "MIRJAM" MAKARSKA | 166d | 2017-11-10 | 2018-06-30 | 0d | finish no earlier than 2018-06-30 |
| 3 | 2 | PRIPREMNI RADOVI | 5d | 2017-11-13 | 2017-11-17 | 161d | finish no earlier than 2017-11-17 |
| 4 | 3 | ZEMLJANI RADOVI | 1d? | 2017-11-24 | 2017-11-24 | 155d |  |
| 5 | 4 | široki iskop | 15d | 2017-11-13 | 2017-12-01 | 150d | start no earlier than 2017-11-13 |
| 6 | 5 | zatrpavanje objekta | 12d | 2018-01-16 | 2018-01-31 | 107d | start no earlier than 2018-01-16 |
| 7 | 6 | iskop za instalacije | 12d | 2018-02-01 | 2018-02-16 | 95d | start no earlier than 2018-02-01 |
| 8 | 7 | iskop za ogradne zidove | 8d | 2018-02-19 | 2018-02-28 | 87d | start no earlier than 2018-02-19 |
| 9 | 8 | planiranje terena | 15d | 2018-03-08 | 2018-03-28 | 67d | start no earlier than 2018-03-08 |
| 10 | 9 | BETONSKI RADOVI | 1d? | 2017-11-24 | 2017-11-24 | 155d |  |
| 11 | 10 | podložni beton dilatacije A | 2d | 2017-12-04 | 2017-12-05 | 148d | start no earlier than 2017-12-04 |
| 12 | 11 | hidroizolacija podne ploče dilatacije A | 1d | 2017-12-05 | 2017-12-05 | 148d | start no earlier than 2017-12-05 |
| 13 | 12 | Izrada podne ploče dilatacije A | 4d | 2017-12-07 | 2017-12-12 | 143d | start no earlier than 2017-12-07 |
| 14 | 13 | izrada zidova podruma dilataije A | 7d | 2017-12-13 | 2017-12-21 | 136d | start no earlier than 2017-12-13 |
| 15 | 14 | izrada stropne ploče podruma | 5d | 2017-12-18 | 2017-12-22 | 135d | start no earlier than 2017-12-18 |
| 16 | 15 | zidovi garaže (podrum 2) | 8d | 2018-01-03 | 2018-01-12 | 120d | start no earlier than 2018-01-03 |
| 17 | 16 | ploča iznad garaže | 7d | 2018-01-05 | 2018-01-15 | 119d | start no earlier than 2018-01-05 |
| 18 | 17 | zidovi prizemlja dilatacije A | 6d | 2018-01-16 | 2018-01-23 | 113d | start no earlier than 2018-01-16 |
| 19 | 18 | ploča iznad prizemlja dilatacije A | 7d | 2018-01-19 | 2018-01-29 | 109d | start no earlier than 2018-01-19 |
| 20 | 19 | zidovi I kata dilatacije A | 7d | 2018-01-29 | 2018-02-06 | 103d | start no earlier than 2018-01-29 |
| 21 | 20 | ploča iznad I kata dilatacije A | 7d | 2018-01-31 | 2018-02-08 | 101d | start no earlier than 2018-01-31 |
| 22 | 21 | zidovi II kata dilatacije A | 6d | 2018-02-09 | 2018-02-16 | 95d | start no earlier than 2018-02-09 |
| 23 | 22 | ploča iznad II kata dilatacije A | 6d | 2018-02-12 | 2018-02-19 | 94d | start no earlier than 2018-02-12 |
| 24 | 23 | zidovi nadgrađa | 5d | 2018-02-20 | 2018-02-26 | 89d | start no earlier than 2018-02-20 |
| 25 | 24 | ploča iznad nadgrađa | 4d | 2018-02-23 | 2018-02-28 | 87d | start no earlier than 2018-02-23 |
| 26 | 25 | podložni beton dilatacije b | 1d | 2018-01-08 | 2018-01-08 | 124d | start no earlier than 2018-01-08 |
| 27 | 26 | hidroizolacija podne ploče dilatacije B | 1d | 2018-01-09 | 2018-01-09 | 123d | start no earlier than 2018-01-09 |
| 28 | 27 | podna ploča dilatacije B | 5d | 2018-01-10 | 2018-01-16 | 118d | start no earlier than 2018-01-10 |
| 29 | 28 | zidovi podruma 2 dilatacija B | 6d | 2018-01-17 | 2018-01-24 | 112d | start no earlier than 2018-01-17 |
| 30 | 29 | ploča iznad podruma 2 | 6d | 2018-01-22 | 2018-01-29 | 109d | start no earlier than 2018-01-22 |
| 31 | 30 | zidovi prizemlja dilatacije B | 6d | 2018-01-30 | 2018-02-06 | 103d | start no earlier than 2018-01-30 |
| 32 | 31 | ploča iznad prizemlja dilatacije B | 5d | 2018-02-01 | 2018-02-07 | 102d | start no earlier than 2018-02-01 |
| 33 | 32 | zidovi I kata dilatacije B | 6d | 2018-02-08 | 2018-02-15 | 96d | start no earlier than 2018-02-08 |
| 34 | 33 | ploča iznad I kata dilatacije B | 7d | 2018-02-12 | 2018-02-20 | 93d | start no earlier than 2018-02-10 |
| 35 | 34 | zidovi II kata dilatacije B | 6d | 2018-02-19 | 2018-02-26 | 89d | start no earlier than 2018-02-19 |
| 36 | 35 | ploča iznad II kata filatacije B | 8d | 2018-02-21 | 2018-03-02 | 85d | start no earlier than 2018-02-21 |
| 37 | 36 | izrada parapetnih zidova po krovu | 5d | 2018-03-05 | 2018-03-09 | 80d | start no earlier than 2018-03-03 |
| 38 | 37 | betoniranje bazenske školjke | 10d | 2018-03-12 | 2018-03-23 | 70d | start no earlier than 2018-03-12 |
| 39 | 38 | izrada ogradnih zidova | 9d | 2018-02-26 | 2018-03-08 | 81d | start no earlier than 2018-02-26 |
| 40 | 39 | izrada estriha | 39d | 2018-03-01 | 2018-04-24 | 69d | start no earlier than 2018-03-01 |
| 41 | 40 | HIDROIZOLATERSKI RADOVI | 1d? | 2017-11-24 | 2017-11-24 | 155d |  |
| 42 | 41 | hidroizolacija zidova podruma 1 | 6d | 2018-01-03 | 2018-01-10 | 122d | start no earlier than 2018-01-03 |
| 43 | 42 | hidroizolacija zidova podruma 2 | 12d | 2018-01-10 | 2018-01-25 | 111d | start no earlier than 2018-01-10 |
| 44 | 43 | izrada ravnog krova | 11d | 2018-03-26 | 2018-04-09 | 59d | start no earlier than 2018-03-26 |
| 45 | 44 | hidroizolacija kupaonica | 41d | 2018-03-08 | 2018-05-03 | 62d | start no earlier than 2018-03-08 |
| 46 | 45 | hidroizolacija terasa | 43d | 2018-03-08 | 2018-05-07 | 60d | start no earlier than 2018-03-08 |
| 47 | 46 | ZIDARSKI RADOVI | 1d? | 2017-11-24 | 2017-11-24 | 155d |  |
| 48 | 47 | zidanje pregradnih zidova | 32d | 2018-02-02 | 2018-03-19 | 74d | start no earlier than 2018-02-02 |
| 49 | 48 | žbukanje zidova I stropova | 43d | 2018-02-14 | 2018-04-13 | 55d | start no earlier than 2018-02-14 |
| 50 | 49 | izrada fasade | 50d | 2018-04-02 | 2018-06-08 | 36d | start no earlier than 2018-04-02 |
| 51 | 50 | VANJSKA STOLARIJA | 17d | 2018-03-01 | 2018-03-23 | 70d | start no earlier than 2018-03-01 |
| 52 | 51 | INSTALACIJE | 1d? | 2017-11-24 | 2017-11-24 | 155d |  |
| 53 | 52 | I faza | 71d | 2017-12-01 | 2018-03-09 | 80d | start no earlier than 2017-12-01 |
| 54 | 53 | II faza | 36d | 2018-02-05 | 2018-03-26 | 69d | start no earlier than 2018-02-05 |
| 55 | 54 | montaža I ispitivanje | 57d | 2018-04-02 | 2018-06-19 | 29d | start no earlier than 2018-03-31 |
| 56 | 55 | GIPSKARTONSKI RADOVI | 1d? | 2017-11-24 | 2017-11-24 | 155d |  |
| 57 | 56 | zidovi | 49d | 2018-02-19 | 2018-04-26 | 67d | start no earlier than 2018-02-19 |
| 58 | 57 | stropovi | 18d | 2018-03-12 | 2018-04-04 | 62d | start no earlier than 2018-03-12 |
| 59 | 58 | KERAMIČARSKI RADOVI | 61d | 2018-03-19 | 2018-06-11 | 35d | start no earlier than 2018-03-19 |
| 60 | 59 | MOLERSKI RADOVI | 35d | 2018-03-26 | 2018-05-11 | 56d | start no earlier than 2018-03-26 |
| 61 | 60 | PODOPOLAGAČKI RADOVI | 35d | 2018-04-16 | 2018-06-01 | 41d | start no earlier than 2018-04-16 |
| 62 | 61 | BRAVARSKI RADOVI | 13d | 2018-05-15 | 2018-05-31 | 42d | start no earlier than 2018-05-15 |
| 63 | 62 | UGRADNJA LIFTOVA | 29d | 2018-04-02 | 2018-05-10 | 57d | start no earlier than 2018-04-02 |
| 64 | 63 | MONTAŽA NAMJEŠTAJA | 36d | 2018-05-04 | 2018-06-22 | 26d | start no earlier than 2018-05-04 |
| 65 | 64 | UREĐIVANJE OKOLIŠA | 15d | 2018-06-01 | 2018-06-21 | 27d | start no earlier than 2018-06-01 |
| 66 | 65 | ZAVRŠNO ČIŠĆENJE | 10d | 2018-06-18 | 2018-06-30 | 0d | finish no earlier than 2018-06-30 |
